# FR_1642_07

Schedule from MS Project, 2017-10-03 to 2018-08-22, status date 2017-11-08, costs in €, A marks actual dates.
SGI

## Calendars

- Standard: Mon-Fri 08:00-12:00, 13:00-17:00; Sat-Sun off.

## Resources

| Resource | Rate |
| --- | --- |
| Gestionnaire de projet | 75 |
| Technicien de projet | 50 |
| Directeur Achat | 50 |
| Acheteur | 35 |
| Inégnieur Jr | 60 |
| Inégnieur Sr | 90 |
| Marketing | 35 |
| Directeur Qualité | 50 |
| Inspecteur Qualité | 25 |
| Exécutif | 125 |
| Responsable Production | 75 |
| Gestionnaire des Ressources Humaines | 25 |
| Legal | 155 |

## Schedule

| ID | WBS | Task | Type | Duration | Start | Finish | Predecessors | Complete | Remaining | Baseline start | Baseline finish | Baseline duration | Total slack | Free slack | Resources | Work | Actual work | Cost | Baseline cost | Actual cost |
| --- | --- | --- | --- | --- | --- | --- | --- | --- | --- | --- | --- | --- | --- | --- | --- | --- | --- | --- | --- | --- |
| 1 | 1 | Début du projet |  | 1d | 2017-10-03 A | 2017-10-03 A |  | 100% |  | 2017-10-03 | 2017-10-03 | 1d |  |  | Gestionnaire de projet | 8h | 8h | 600 | 600 | 600 |
| 2 | 2 | **Initiation** |  | 11d | 2017-10-04 A | 2017-10-18 A |  | 100% |  | 2017-10-04 | 2017-10-11 | 6d |  |  |  | 176h | 176h | 11,000 | 6,000 | 11,000 |
| 3 | 2.1 | Compléter l'étude de cas |  | 10d | 2017-10-04 A | 2017-10-17 A | 1 | 100% |  | 2017-10-04 | 2017-10-10 | 5d |  |  | Marketing; Inégnieur Sr | 160h | 160h | 10,000 | 5,000 | 10,000 |
| 4 | 2.2 | Présenter l'étude de cas au committé exécutif |  | 1d | 2017-10-18 A | 2017-10-18 A | 3 | 100% |  | 2017-10-11 | 2017-10-11 | 1d |  |  | Inégnieur Sr; Marketing | 16h | 16h | 1,000 | 1,000 | 1,000 |
| 5 | 2.3 | Approbation de l'étude de cas | milestone | 0d | 2017-10-18 A | 2017-10-18 A | 4 | 100% |  | 2017-10-11 | 2017-10-11 | 0d |  |  | Exécutif |  |  |  |  |  |
| 6 | 3 | **Définition** |  | 45d | 2017-10-19 A | 2017-12-20 |  | 33% | 30.25d | 2017-10-12 | 2017-11-09 | 21d | 0d |  |  | 1024h | 230h | 80,560 | 35,360 | 14,750 |
| 7 | 3.1 | Préparer la charte de projet |  | 14d | 2017-10-19 A | 2017-11-07 A | 5 | 100% |  | 2017-10-12 | 2017-10-25 | 10d |  |  | Gestionnaire de projet; Technicien de projet | 224h | 224h | 14,000 | 10,000 | 14,000 |
| 8 | 3.2 | Approuver la charte de projet |  | 15d | 2017-11-08 A | 2017-11-28 | 7 | 5% | 14.25d | 2017-10-26 | 2017-11-01 | 5d | 0d |  | Exécutif | 120h | 6h | 15,000 | 5,000 | 750 |
| 9 | 3.3 | Développer l'équipe de travail |  | 15d | 2017-11-29 | 2017-12-19 | 8 |  |  | 2017-11-02 | 2017-11-08 | 5d | 0d |  | Directeur Qualité; Exécutif; Gestionnaire de projet; Inégnieur Sr; Technicien de projet | 600h |  | 46,800 | 15,600 |  |
| 10 | 3.4 | Procéder à la rencontre de démarrage du projet |  | 1d | 2017-12-20 | 2017-12-20 | 9 |  |  | 2017-11-09 | 2017-11-09 | 1d | 0d |  | Acheteur; Directeur Achat; Directeur Qualité; Exécutif; Gestionnaire de projet; Inégnieur Jr; Inégnieur Sr; Inspecteur Qualité; Marketing; Technicien de projet | 80h |  | 4,760 | 4,760 |  |
| 11 | 4 | **Planification du projet** |  | 144d | 2017-12-21 | 2018-07-10 |  |  |  | 2017-11-10 | 2018-05-30 | 144d | 0d |  |  | 7520h |  | 467,200 | 464,400 |  |
| 12 | 4.1 | **Prototype 1** |  | 87d | 2017-12-21 | 2018-04-20 |  |  |  | 2017-11-10 | 2018-02-26 | 77d | 0d |  |  | 2560h |  | 157,600 | 154,800 |  |
| 13 | 4.1.1 | **Approvisionnement** |  | 35d | 2017-12-21 | 2018-02-07 |  |  |  | 2017-11-10 | 2017-12-14 | 25d | 88d |  |  | 440h |  | 22,000 | 19,200 |  |
| 14 | 4.1.1.1 | Développer les plans de matières premières |  | 5d | 2017-12-21 | 2017-12-27 | 10 |  |  | 2017-11-10 | 2017-11-16 | 5d | 88d | 0d | Acheteur; Inégnieur Sr | 80h |  | 5,000 | 5,000 |  |
| 15 | 4.1.1.2 | Faire un appel d'offre sur le marché |  | 25d | 2017-12-28 | 2018-01-31 | 14 |  |  | 2017-11-17 | 2017-12-07 | 15d | 88d | 0d | Acheteur | 200h |  | 7,000 | 4,200 |  |
| 16 | 4.1.1.3 | Sélectionner le fournisseur |  | 5d | 2018-02-01 | 2018-02-07 | 15 |  |  | 2017-12-08 | 2017-12-14 | 5d | 88d | 0d | Acheteur; Directeur Achat; Gestionnaire de projet; Inégnieur Sr | 160h |  | 10,000 | 10,000 |  |
| 17 | 4.1.2 | **Ingénierie de produit** |  | 20d | 2017-12-21 | 2018-01-17 |  |  |  | 2017-11-10 | 2017-12-07 | 20d | 0d |  |  | 200h |  | 14,400 | 14,400 |  |
| 18 | 4.1.2.1 | Développer le design préliminaire |  | 10d | 2017-12-21 | 2018-01-03 | 10 |  |  | 2017-11-10 | 2017-11-23 | 10d | 0d |  | Inégnieur Jr | 80h |  | 4,800 | 4,800 |  |
| 19 | 4.1.2.2 | Compléter l'étude de faisabilité |  | 5d | 2018-01-04 | 2018-01-10 | 18 |  |  | 2017-11-24 | 2017-11-30 | 5d | 155d | 0d | Inégnieur Jr; Inégnieur Sr | 80h |  | 6,000 | 6,000 |  |
| 20 | 4.1.2.3 | Élaborer le processus de fabrication du prototype |  | 5d | 2018-01-11 | 2018-01-17 | 19 |  |  | 2017-12-01 | 2017-12-07 | 5d | 155d |  | Inégnieur Sr | 40h |  | 3,600 | 3,600 |  |
| 21 | 4.1.3 | **Production** |  | 52d | 2018-02-08 | 2018-04-20 |  |  |  | 2017-12-15 | 2018-02-26 | 52d | 88d |  |  | 1576h |  | 99,200 | 99,200 |  |
| 22 | 4.1.3.1 | Assembler le matériel nécessaire |  | 15d | 2018-02-08 | 2018-02-28 | 16 |  |  | 2017-12-15 | 2018-01-04 | 15d | 88d | 0d | Gestionnaire de projet; Inégnieur Jr; Technicien de projet; Acheteur; Responsable Production | 600h |  | 35,400 | 35,400 |  |
| 23 | 4.1.3.2 | Développer le processus de production |  | 5d | 2018-03-01 | 2018-03-07 | 22 |  |  | 2018-01-05 | 2018-01-11 | 5d | 88d | 0d | Inégnieur Jr; Inégnieur Sr; Responsable Production; Technicien de projet | 160h |  | 11,000 | 11,000 |  |
| 24 | 4.1.3.3 | Faire les changements nécessaires à la production |  | 10d | 2018-03-08 | 2018-03-21 | 23 |  |  | 2018-01-12 | 2018-01-25 | 10d | 88d | 0d | Inégnieur Jr; Responsable Production | 160h |  | 10,800 | 10,800 |  |
| 25 | 4.1.3.4 | Compléter le prototype |  | 20d | 2018-03-22 | 2018-04-18 | 24 |  |  | 2018-01-26 | 2018-02-22 | 20d | 88d | 0d | Gestionnaire de projet; Inégnieur Jr; Responsable Production; Technicien de projet | 640h |  | 41,600 | 41,600 |  |

| ID | WBS | Task | Type | Duration | Start | Finish | Predecessors | Baseline start | Baseline finish | Baseline duration | Total slack | Free slack | Resources | Work | Cost | Baseline cost |
| --- | --- | --- | --- | --- | --- | --- | --- | --- | --- | --- | --- | --- | --- | --- | --- | --- |
| 26 | 4.1.3.5 | **Qualité** |  | 2d | 2018-04-19 | 2018-04-20 |  | 2018-02-23 | 2018-02-26 | 2d | 88d |  |  | 16h | 400 | 400 |
| 27 | 4.1.3.5.1 | Inspecter le produit |  | 2d | 2018-04-19 | 2018-04-20 | 25 | 2018-02-23 | 2018-02-26 | 2d | 88d | 0d | Inspecteur Qualité | 16h | 400 | 400 |
| 28 | 4.1.3.5.2 | Approuver le produit pour expédition au client | milestone | 0d | 2018-04-20 | 2018-04-20 | 27 | 2018-02-26 | 2018-02-26 | 0d | 88d |  | Inspecteur Qualité |  |  |  |
| 29 | 4.1.4 | **Marketing** |  | 21d | 2018-01-04 | 2018-02-01 |  | 2017-11-24 | 2017-12-22 | 21d | 0d |  |  | 344h | 22,000 | 22,000 |
| 30 | 4.1.4.1 | Élaborer le plan marketing |  | 10d | 2018-01-04 | 2018-01-17 | 18 | 2017-11-24 | 2017-12-07 | 10d | 0d |  | Gestionnaire de projet; Marketing | 160h | 8,800 | 8,800 |
| 31 | 4.1.4.2 | Présenter le prototype au client |  | 1d | 2018-01-18 | 2018-01-18 | 30 | 2017-12-08 | 2017-12-08 | 1d | 0d |  | Gestionnaire de projet; Inégnieur Sr; Marketing | 24h | 1,600 | 1,600 |
| 32 | 4.1.4.3 | Aviser des changements recquis |  | 5d | 2018-01-19 | 2018-01-25 | 31 | 2017-12-11 | 2017-12-15 | 5d | 0d |  | Gestionnaire de projet; Inégnieur Sr | 80h | 6,600 | 6,600 |
| 33 | 4.1.4.4 | Compléter le rapport du feedback client |  | 5d | 2018-01-26 | 2018-02-01 | 32 | 2017-12-18 | 2017-12-22 | 5d | 144d |  | Marketing; Inégnieur Sr | 80h | 5,000 | 5,000 |
| 34 | 4.2 | **Prototype 2** |  | 77d | 2018-01-26 | 2018-05-14 |  | 2017-12-18 | 2018-04-03 | 77d | 0d |  |  | 2480h | 154,800 | 154,800 |
| 35 | 4.2.1 | **Approvisionnement** |  | 25d | 2018-01-26 | 2018-03-01 |  | 2017-12-18 | 2018-01-19 | 25d | 0d |  |  | 360h | 19,200 | 19,200 |
| 36 | 4.2.1.1 | Développer les plans de matières premières |  | 5d | 2018-01-26 | 2018-02-01 | 32 | 2017-12-18 | 2017-12-22 | 5d | 0d |  | Acheteur; Inégnieur Sr | 80h | 5,000 | 5,000 |
| 37 | 4.2.1.2 | Faire un appel d'offre sur le marché |  | 15d | 2018-02-02 | 2018-02-22 | 36 | 2017-12-25 | 2018-01-12 | 15d | 0d |  | Acheteur | 120h | 4,200 | 4,200 |
| 38 | 4.2.1.3 | Sélectionner le fournisseur |  | 5d | 2018-02-23 | 2018-03-01 | 37 | 2018-01-15 | 2018-01-19 | 5d | 0d |  | Acheteur; Directeur Achat; Gestionnaire de projet; Inégnieur Sr | 160h | 10,000 | 10,000 |
| 39 | 4.2.2 | **Ingénierie de produit** |  | 20d | 2018-01-26 | 2018-02-22 |  | 2017-12-18 | 2018-01-12 | 20d | 129d |  |  | 200h | 14,400 | 14,400 |
| 40 | 4.2.2.1 | Développer le design préliminaire |  | 10d | 2018-01-26 | 2018-02-08 | 32 | 2017-12-18 | 2017-12-29 | 10d | 129d | 0d | Inégnieur Jr | 80h | 4,800 | 4,800 |
| 41 | 4.2.2.2 | Compléter l'étude de faisabilité |  | 5d | 2018-02-09 | 2018-02-15 | 40 | 2018-01-01 | 2018-01-05 | 5d | 129d | 0d | Inégnieur Jr; Inégnieur Sr | 80h | 6,000 | 6,000 |
| 42 | 4.2.2.3 | Élaborer le processus de fabrication du prototype |  | 5d | 2018-02-16 | 2018-02-22 | 41 | 2018-01-08 | 2018-01-12 | 5d | 129d |  | Inégnieur Sr | 40h | 3,600 | 3,600 |
| 43 | 4.2.3 | **Production** |  | 52d | 2018-03-02 | 2018-05-14 |  | 2018-01-22 | 2018-04-03 | 52d | 72d |  |  | 1576h | 99,200 | 99,200 |
| 44 | 4.2.3.1 | Assembler le matériel nécessaire |  | 15d | 2018-03-02 | 2018-03-22 | 38 | 2018-01-22 | 2018-02-09 | 15d | 72d | 0d | Gestionnaire de projet; Inégnieur Jr; Technicien de projet; Acheteur; Responsable Production | 600h | 35,400 | 35,400 |
| 45 | 4.2.3.2 | Développer le processus de production |  | 5d | 2018-03-23 | 2018-03-29 | 44 | 2018-02-12 | 2018-02-16 | 5d | 72d | 0d | Inégnieur Jr; Inégnieur Sr; Responsable Production; Technicien de projet | 160h | 11,000 | 11,000 |
| 46 | 4.2.3.3 | Faire les changements nécessaires à la production |  | 10d | 2018-03-30 | 2018-04-12 | 45 | 2018-02-19 | 2018-03-02 | 10d | 72d | 0d | Inégnieur Jr; Responsable Production | 160h | 10,800 | 10,800 |
| 47 | 4.2.3.4 | Compléter le prototype |  | 20d | 2018-04-13 | 2018-05-10 | 46 | 2018-03-05 | 2018-03-30 | 20d | 72d | 0d | Gestionnaire de projet; Inégnieur Jr; Responsable Production; Technicien de projet | 640h | 41,600 | 41,600 |
| 48 | 4.2.3.5 | **Qualité** |  | 2d | 2018-05-11 | 2018-05-14 |  | 2018-04-02 | 2018-04-03 | 2d | 72d |  |  | 16h | 400 | 400 |
| 49 | 4.2.3.5.1 | Inspecter le produit |  | 2d | 2018-05-11 | 2018-05-14 | 47 | 2018-04-02 | 2018-04-03 | 2d | 72d | 0d | Inspecteur Qualité | 16h | 400 | 400 |
| 50 | 4.2.3.5.2 | Approuver le produit pour expédition au client | milestone | 0d | 2018-05-14 | 2018-05-14 | 49 | 2018-04-03 | 2018-04-03 | 0d | 72d |  | Inspecteur Qualité |  |  |  |

| ID | WBS | Task | Type | Duration | Start | Finish | Predecessors | Baseline start | Baseline finish | Baseline duration | Total slack | Free slack | Resources | Work | Cost | Baseline cost |
| --- | --- | --- | --- | --- | --- | --- | --- | --- | --- | --- | --- | --- | --- | --- | --- | --- |
| 51 | 4.2.4 | **Marketing** |  | 21d | 2018-03-02 | 2018-03-30 |  | 2018-01-22 | 2018-02-19 | 21d | 0d |  |  | 344h | 22,000 | 22,000 |
| 52 | 4.2.4.1 | Élaborer le plan marketing |  | 10d | 2018-03-02 | 2018-03-15 | 38 | 2018-01-22 | 2018-02-02 | 10d | 0d |  | Gestionnaire de projet; Marketing | 160h | 8,800 | 8,800 |
| 53 | 4.2.4.2 | Présenter le prototype au client |  | 1d | 2018-03-16 | 2018-03-16 | 52 | 2018-02-05 | 2018-02-05 | 1d | 0d |  | Gestionnaire de projet; Inégnieur Sr; Marketing | 24h | 1,600 | 1,600 |
| 54 | 4.2.4.3 | Aviser des changements recquis |  | 5d | 2018-03-19 | 2018-03-23 | 53 | 2018-02-06 | 2018-02-12 | 5d | 0d |  | Gestionnaire de projet; Inégnieur Sr | 80h | 6,600 | 6,600 |
| 55 | 4.2.4.4 | Compléter le rapport du feedback client |  | 5d | 2018-03-26 | 2018-03-30 | 54 | 2018-02-13 | 2018-02-19 | 5d | 103d |  | Marketing; Inégnieur Sr | 80h | 5,000 | 5,000 |
| 56 | 4.3 | **Prototype Final** |  | 77d | 2018-03-26 | 2018-07-10 |  | 2018-02-13 | 2018-05-30 | 77d | 0d |  |  | 2480h | 154,800 | 154,800 |
| 57 | 4.3.1 | **Approvisionnement** |  | 25d | 2018-03-26 | 2018-04-27 |  | 2018-02-13 | 2018-03-19 | 25d | 31d |  |  | 360h | 19,200 | 19,200 |
| 58 | 4.3.1.1 | Développer les plans de matières premières |  | 5d | 2018-03-26 | 2018-03-30 | 54 | 2018-02-13 | 2018-02-19 | 5d | 31d | 0d | Acheteur; Inégnieur Sr | 80h | 5,000 | 5,000 |
| 59 | 4.3.1.2 | Faire un appel d'offre sur le marché |  | 15d | 2018-04-02 | 2018-04-20 | 58 | 2018-02-20 | 2018-03-12 | 15d | 31d | 0d | Acheteur | 120h | 4,200 | 4,200 |
| 60 | 4.3.1.3 | Sélectionner le fournisseur |  | 5d | 2018-04-23 | 2018-04-27 | 59 | 2018-03-13 | 2018-03-19 | 5d | 31d | 0d | Acheteur; Directeur Achat; Gestionnaire de projet; Inégnieur Sr | 160h | 10,000 | 10,000 |
| 61 | 4.3.2 | **Ingénierie de produit** |  | 20d | 2018-03-26 | 2018-04-20 |  | 2018-02-13 | 2018-03-12 | 20d | 88d |  |  | 200h | 14,400 | 14,400 |
| 62 | 4.3.2.1 | Développer le design préliminaire |  | 10d | 2018-03-26 | 2018-04-06 | 54 | 2018-02-13 | 2018-02-26 | 10d | 88d | 0d | Inégnieur Jr | 80h | 4,800 | 4,800 |
| 63 | 4.3.2.2 | Compléter l'étude de faisabilité |  | 5d | 2018-04-09 | 2018-04-13 | 62 | 2018-02-27 | 2018-03-05 | 5d | 88d | 0d | Inégnieur Jr; Inégnieur Sr | 80h | 6,000 | 6,000 |
| 64 | 4.3.2.3 | Élaborer le processus de fabrication du prototype |  | 5d | 2018-04-16 | 2018-04-20 | 63 | 2018-03-06 | 2018-03-12 | 5d | 88d |  | Inégnieur Sr | 40h | 3,600 | 3,600 |
| 65 | 4.3.3 | **Production** |  | 50d | 2018-04-30 | 2018-07-06 |  | 2018-03-20 | 2018-05-28 | 50d | 31d |  |  | 1560h | 98,800 | 98,800 |
| 66 | 4.3.3.1 | Assembler le matériel nécessaire |  | 15d | 2018-04-30 | 2018-05-18 | 60 | 2018-03-20 | 2018-04-09 | 15d | 31d | 0d | Gestionnaire de projet; Inégnieur Jr; Technicien de projet; Acheteur; Responsable Production | 600h | 35,400 | 35,400 |
| 67 | 4.3.3.2 | Développer le processus de production |  | 5d | 2018-05-21 | 2018-05-25 | 66 | 2018-04-10 | 2018-04-16 | 5d | 31d | 0d | Inégnieur Jr; Inégnieur Sr; Responsable Production; Technicien de projet | 160h | 11,000 | 11,000 |
| 68 | 4.3.3.3 | Faire les changements nécessaires à la production |  | 10d | 2018-05-28 | 2018-06-08 | 67 | 2018-04-17 | 2018-04-30 | 10d | 31d | 0d | Inégnieur Jr; Responsable Production | 160h | 10,800 | 10,800 |
| 69 | 4.3.3.4 | Compléter le prototype |  | 20d | 2018-06-11 | 2018-07-06 | 68 | 2018-05-01 | 2018-05-28 | 20d | 31d | 0d | Gestionnaire de projet; Inégnieur Jr; Responsable Production; Technicien de projet | 640h | 41,600 | 41,600 |
| 70 | 4.3.4 | **Qualité** |  | 2d | 2018-07-09 | 2018-07-10 |  | 2018-05-29 | 2018-05-30 | 2d | 31d |  |  | 16h | 400 | 400 |
| 71 | 4.3.4.1 | Inspecter le produit |  | 2d | 2018-07-09 | 2018-07-10 | 69 | 2018-05-29 | 2018-05-30 | 2d | 31d | 0d | Inspecteur Qualité | 16h | 400 | 400 |
| 72 | 4.3.4.2 | Approuver le produit pour expédition au client | milestone | 0d | 2018-07-10 | 2018-07-10 | 71 | 2018-05-30 | 2018-05-30 | 0d | 31d |  | Inspecteur Qualité |  |  |  |
| 73 | 4.3.5 | **Marketing** |  | 21d | 2018-03-26 | 2018-04-23 |  | 2018-02-13 | 2018-03-13 | 21d | 0d |  |  | 344h | 22,000 | 22,000 |
| 74 | 4.3.5.1 | Élaborer le plan marketing |  | 10d | 2018-03-26 | 2018-04-06 | 54 | 2018-02-13 | 2018-02-26 | 10d | 0d |  | Gestionnaire de projet; Marketing | 160h | 8,800 | 8,800 |
| 75 | 4.3.5.2 | Présenter le prototype au client |  | 1d | 2018-04-09 | 2018-04-09 | 74 | 2018-02-27 | 2018-02-27 | 1d | 0d |  | Gestionnaire de projet; Inégnieur Sr; Marketing | 24h | 1,600 | 1,600 |
| 76 | 4.3.5.3 | Aviser des changements recquis |  | 5d | 2018-04-10 | 2018-04-16 | 75 | 2018-02-28 | 2018-03-06 | 5d | 0d |  | Gestionnaire de projet; Inégnieur Sr | 80h | 6,600 | 6,600 |
| 77 | 4.3.5.4 | Compléter le rapport du feedback client |  | 5d | 2018-04-17 | 2018-04-23 | 76 | 2018-03-07 | 2018-03-13 | 5d | 0d |  | Marketing; Inégnieur Sr | 80h | 5,000 | 5,000 |
| 78 | 4.3.6 | Approbation du client du prototype et transfer à la production finale | milestone | 0d | 2018-04-23 | 2018-04-23 | 77 | 2018-03-13 | 2018-03-13 | 0d | 0d |  | Directeur Achat; Directeur Qualité; Exécutif; Gestionnaire de projet; Inégnieur Sr; Responsable Production |  |  |  |

| ID | WBS | Task | Type | Duration | Start | Finish | Predecessors | Baseline start | Baseline finish | Baseline duration | Total slack | Free slack | Resources | Work | Cost | Baseline cost |
| --- | --- | --- | --- | --- | --- | --- | --- | --- | --- | --- | --- | --- | --- | --- | --- | --- |
| 79 | 5 | **Execution** |  | 87d | 2018-04-24 | 2018-08-22 |  | 2018-03-14 | 2018-07-12 | 87d | 0d |  |  | 4672h | 286,360 | 286,360 |
| 80 | 5.1 | **Ingénierie de produit** |  | 60d | 2018-04-24 | 2018-07-16 |  | 2018-03-14 | 2018-06-05 | 60d | 27d |  |  | 1480h | 97,600 | 97,600 |
| 81 | 5.1.1 | Finaliser les plans de produits |  | 15d | 2018-04-24 | 2018-05-14 | 78 | 2018-03-14 | 2018-04-03 | 15d | 27d | 0d | Inégnieur Jr; Inégnieur Sr | 240h | 18,000 | 18,000 |
| 82 | 5.1.2 | Préprarer la cédule de maintenance |  | 10d | 2018-05-15 | 2018-05-28 | 81 | 2018-04-04 | 2018-04-17 | 10d | 27d | 0d | Inégnieur Jr; Technicien de projet | 160h | 8,800 | 8,800 |
| 83 | 5.1.3 | Élaborer le processus du fabrication |  | 20d | 2018-05-29 | 2018-06-25 | 82 | 2018-04-18 | 2018-05-15 | 20d | 27d | 0d | Inégnieur Jr; Responsable Production; Technicien de projet | 480h | 29,600 | 29,600 |
| 84 | 5.1.4 | Formation des techniciens procédés |  | 15d | 2018-06-26 | 2018-07-16 | 83 | 2018-05-16 | 2018-06-05 | 15d | 27d |  | Inégnieur Jr; Inégnieur Sr; Technicien de projet | 360h | 24,000 | 24,000 |
| 85 | 5.1.5 | Compléter fichier du produit pour transfer à la production |  | 10d | 2018-06-26 | 2018-07-09 | 83 | 2018-05-16 | 2018-05-29 | 10d | 32d |  | Directeur Qualité; Gestionnaire de projet; Inégnieur Sr | 240h | 17,200 | 17,200 |
| 86 | 5.2 | **Qualité** |  | 16d | 2018-04-24 | 2018-05-15 |  | 2018-03-14 | 2018-04-04 | 16d | 61d |  |  | 408h | 15,400 | 15,400 |
| 87 | 5.2.1 | Compléter l'approbation client du produit |  | 1d | 2018-04-24 | 2018-04-24 | 78 | 2018-03-14 | 2018-03-14 | 1d | 61d | 0d | Directeur Qualité | 8h | 400 | 400 |
| 88 | 5.2.2 | Élaborer les critères d'inspection |  | 5d | 2018-04-25 | 2018-05-01 | 87 | 2018-03-15 | 2018-03-21 | 5d | 61d | 0d | Directeur Qualité; Inspecteur Qualité | 80h | 3,000 | 3,000 |
| 89 | 5.2.3 | Formation des inspecteurs qualités |  | 10d | 2018-05-02 | 2018-05-15 | 88 | 2018-03-22 | 2018-04-04 | 10d | 61d | 29d | Directeur Qualité; Inspecteur Qualité; Technicien de projet; Gestionnaire des Ressources Humaines | 320h | 12,000 | 12,000 |
| 90 | 5.3 | **Ressources humaines** |  | 30d | 2018-04-24 | 2018-06-04 |  | 2018-03-14 | 2018-04-24 | 30d | 57d |  |  | 1120h | 58,000 | 58,000 |
| 91 | 5.3.1 | Embaucher les nouveaux opérateurs |  | 20d | 2018-04-24 | 2018-05-21 | 78 | 2018-03-14 | 2018-04-10 | 20d | 57d | 0d | Gestionnaire des Ressources Humaines | 160h | 4,000 | 4,000 |
| 92 | 5.3.2 | Développer le plan de formation |  | 15d | 2018-04-24 | 2018-05-14 | 91SS | 2018-03-14 | 2018-04-03 | 15d | 57d | 0d | Gestionnaire des Ressources Humaines; Gestionnaire de projet; Inégnieur Sr; Responsable Production | 480h | 31,800 | 31,800 |
| 93 | 5.3.3 | Former les nouveaux opérateurs |  | 15d | 2018-05-15 | 2018-06-04 | 92 | 2018-04-04 | 2018-04-24 | 15d | 57d |  | Gestionnaire des Ressources Humaines; Inégnieur Jr; Inspecteur Qualité; Responsable Production | 480h | 22,200 | 22,200 |
| 94 | 5.4 | **Approvisionnement** |  | 87d | 2018-04-24 | 2018-08-22 |  | 2018-03-14 | 2018-07-12 | 87d | 0d |  |  | 1504h | 104,560 | 104,560 |
| 95 | 5.4.1 | Développer les plans finaux des requis de matières premières |  | 10d | 2018-04-24 | 2018-05-07 | 78 | 2018-03-14 | 2018-03-27 | 10d | 0d |  | Acheteur; Directeur Achat | 160h | 6,800 | 6,800 |
| 96 | 5.4.2 | Faire appel d'offres |  | 15d | 2018-05-08 | 2018-05-28 | 95 | 2018-03-28 | 2018-04-17 | 15d | 0d |  | Acheteur | 120h | 4,200 | 4,200 |
| 97 | 5.4.3 | Choisir les fournisseurs |  | 15d | 2018-05-29 | 2018-06-18 | 96 | 2018-04-18 | 2018-05-08 | 15d | 0d |  | Directeur Achat; Directeur Qualité; Gestionnaire de projet; Inégnieur Sr; Responsable Production | 600h | 40,800 | 40,800 |
| 98 | 5.4.4 | Développer le contrat |  | 20d | 2018-06-19 | 2018-07-16 | 97 | 2018-05-09 | 2018-06-05 | 20d | 0d |  | Acheteur | 160h | 5,600 | 5,600 |
| 99 | 5.4.5 | Revoir le contrat par le département législatif |  | 20d | 2018-07-17 | 2018-08-13 | 98 | 2018-06-06 | 2018-07-03 | 20d | 0d |  | Legal | 160h | 24,800 | 24,800 |
| 100 | 5.4.6 | Signer et approuver le contrat |  | 5d | 2018-08-14 | 2018-08-20 | 99 | 2018-07-04 | 2018-07-10 | 5d | 0d |  | Directeur Achat; Directeur Qualité; Exécutif; Gestionnaire de projet; Inégnieur Sr; Responsable Production | 240h | 18,600 | 18,600 |
| 101 | 5.4.7 | Mettre en place le plan d'approvisionnement |  | 2d | 2018-08-21 | 2018-08-22 | 100, 105 | 2018-07-11 | 2018-07-12 | 2d | 0d |  | Acheteur; Gestionnaire de projet; Responsable Production; Technicien de projet | 64h | 3,760 | 3,760 |
| 102 | 5.5 | **Département de production** |  | 72d | 2018-05-14 | 2018-08-22 |  | 2018-04-03 | 2018-07-12 | 72d | 0d |  |  | 160h | 10,800 | 10,800 |
| 103 | 5.5.1 | Accepter le design de produit | milestone | 0d | 2018-05-14 | 2018-05-14 | 81 | 2018-04-03 | 2018-04-03 | 0d | 72d |  | Responsable Production |  |  |  |
| 104 | 5.5.2 | Développer plan de production |  | 10d | 2018-06-26 | 2018-07-09 | 83, 89 | 2018-05-16 | 2018-05-29 | 10d | 32d |  | Responsable Production; Inégnieur Jr | 160h | 10,800 | 10,800 |
| 105 | 5.5.3 | Approuver le plan d'approvisionnement | milestone | 0d | 2018-08-20 | 2018-08-20 | 100 | 2018-07-10 | 2018-07-10 | 0d | 0d |  | Responsable Production |  |  |  |
| 106 | 5.5.4 | Projet transféré aux opérations et début de la prouction | milestone | 0d | 2018-08-22 | 2018-08-22 | 105, 101, 93 | 2018-07-12 | 2018-07-12 | 0d | 0d |  | Responsable Production |  |  |  |
